# Proyecto de Sistematización del AGL Cencosud

Schedule from MS Project, 2023-12-01 to 2024-10-04, status date 2023-12-01.

## Calendars

- Estándar: Mon-Fri 09:00-13:00, 15:00-19:00; Sat-Sun off. Exceptions (off unless hours are given): 2023-12-08 (8 de diciembre), 2023-12-25 (25 de diciembre festivo), 2024-01-01 (1 de enero festivo).

## Schedule

| ID | WBS | Task | Duration | Start | Finish | Predecessors | Total slack | Free slack | Constraint |
| --- | --- | --- | --- | --- | --- | --- | --- | --- | --- |
| 1 | 1 | **CRONOGRAMA DE IMPLEMENTACION DE LA AUTOMATIZACION DEL APROVISIONAMIENTO DE GONDOLAS Y LINEALES** | 218d | 2023-12-01 | 2024-10-04 |  | 0d |  |  |
| 2 | 1.1 | **ETAPA DE ANALISIS** | 40d | 2023-12-01 | 2024-01-30 |  | 0d |  |  |
| 3 | 1.1.1 | **Planificación** | 25d | 2023-12-01 | 2024-01-09 |  | 0d |  |  |
| 4 | 1.1.1.1 | Creación del proyecto en el portal PMO Cencosud | 1d | 2023-12-01 | 2023-12-01 |  | 0d |  |  |
| 5 | 1.1.1.2 | Liberación de las líneas presupuestarias | 5d | 2023-12-04 | 2023-12-11 | 4 | 21d | 6d |  |
| 6 | 1.1.1.3 | Convocar a los proveedores | 8d | 2023-12-20 | 2024-01-02 | 5 | 15d | 0d | finish no earlier than 2024-01-02 |
| 7 | 1.1.1.4 | Selección proveedor | 5d | 2024-01-03 | 2024-01-09 | 6 | 15d |  |  |
| 8 | 1.1.1.5 | Aprobación del presupuesto | 9d | 2023-12-07 | 2023-12-20 | 4 | 26d | 0d | start no earlier than 2023-12-07 |
| 9 | 1.1.1.6 | Kick off del proyecto | 1d | 2023-12-21 | 2023-12-21 | 8 | 26d |  |  |
| 10 | 1.1.2 | **Identificación y análisis** | 17d | 2023-12-04 | 2023-12-28 |  | 0d |  |  |
| 11 | 1.1.2.1 | Levantamiento de subprocesos macro | 4d | 2023-12-04 | 2023-12-07 | 4 | 0d |  |  |
| 12 | 1.1.2.2 | Identificación de interesados | 2d | 2023-12-11 | 2023-12-12 | 11 | 0d |  |  |
| 13 | 1.1.2.3 | Análisis del proceso de aprovisionamiento de góndolas y lineales | 3d | 2023-12-13 | 2023-12-15 | 12 | 0d |  |  |
| 14 | 1.1.2.4 | Análisis del proceso de gestión del inventario | 4d | 2023-12-18 | 2023-12-21 | 13 | 0d |  |  |
| 15 | 1.1.2.5 | Levantamiento de la documentación funcional | 4d | 2023-12-22 | 2023-12-28 | 13, 14 | 0d |  |  |
| 16 | 1.1.3 | **Divulgación del análisis** | 22d | 2023-12-29 | 2024-01-30 |  | 0d |  |  |
| 17 | 1.1.3.1 | Validación detallada de los procesos en conjunto con el proveedor | 7d | 2023-12-29 | 2024-01-09 | 15 | 0d |  |  |
| 18 | 1.1.3.2 | Sesión de aclaración de proceso | 3d | 2024-01-10 | 2024-01-12 | 17 | 0d |  |  |
| 19 | 1.1.3.3 | Identificación y entendimiento de las políticas y prácticas de Tecnología de Cencosud. | 3d | 2024-01-15 | 2024-01-17 | 18 | 0d |  |  |
| 20 | 1.1.3.4 | Documentación y entendimiento de la arquitectura tecnológica actual | 5d | 2024-01-18 | 2024-01-24 | 19 | 0d |  |  |
| 21 | 1.1.3.5 | Análisis de los requerimientos de infraestructura | 3d | 2024-01-25 | 2024-01-29 | 20 | 0d |  |  |
| 22 | 1.1.3.6 | Análisis de requerimientos de almacenamiento de datos | 1d | 2024-01-30 | 2024-01-30 | 21 | 0d |  | start no earlier than 2024-01-30 |
| 23 | 1.2 | **ETAPA DE DISEÑO** | 36d | 2024-01-31 | 2024-03-20 | 2 | 0d |  |  |
| 24 | 1.2.1 | Identificación de la arquitectura preliminar | 6d | 2024-01-31 | 2024-02-07 |  | 0d |  |  |
| 25 | 1.2.2 | Especificación de los componentes del sistema de información | 3d | 2024-02-08 | 2024-02-12 | 24 | 5d | 0d |  |

| ID | WBS | Task | Duration | Start | Finish | Predecessors | Total slack | Free slack | Constraint |
| --- | --- | --- | --- | --- | --- | --- | --- | --- | --- |
| 26 | 1.2.3 | **Diseño arquitectura componentes y elementos del sistema** | 27d | 2024-02-08 | 2024-03-15 |  | 0d |  |  |
| 27 | 1.2.3.1 | Especificación de las variables para construir el modelo de datos | 5d | 2024-02-13 | 2024-02-19 | 25 | 5d | 0d |  |
| 28 | 1.2.3.2 | Arquitectura de contingencia (Elaboracion-aprobacion) | 5d | 2024-02-08 | 2024-02-14 | 24 | 5d |  | start no earlier than 2024-02-08 |
| 29 | 1.2.3.3 | Módulos del sistema (Elaboracion-aprobacion) | 5d | 2024-02-13 | 2024-02-19 | 25 | 10d | 0d |  |
| 30 | 1.2.3.4 | Interfaz de usuario (Elaboracion-aprobacion) | 5d | 2024-02-20 | 2024-02-26 | 29 | 17d |  |  |
| 31 | 1.2.3.5 | Elementos de seguridad del sistema SW/HW | 10d | 2024-02-08 | 2024-02-21 | 24 | 0d |  |  |
| 32 | 1.2.3.6 | Requerimientos de integración | 7d | 2024-02-20 | 2024-02-28 | 24, 25, 27, 29 | 10d | 0d |  |
| 33 | 1.2.3.7 | Casos de uso (Elaboracion-aprobacion) | 5d | 2024-02-29 | 2024-03-06 | 32 | 10d |  |  |
| 34 | 1.2.3.8 | Migración y carga inicial | 7d | 2024-02-20 | 2024-02-28 | 27 | 5d | 0d |  |
| 35 | 1.2.3.9 | Procedimientos de implantación | 5d | 2024-02-29 | 2024-03-06 | 34 | 5d | 0d |  |
| 36 | 1.2.3.10 | Procedimientos de mantenimiento | 5d | 2024-03-07 | 2024-03-13 | 35 | 5d |  |  |
| 37 | 1.2.3.11 | Infraestructura | 8d | 2024-02-22 | 2024-03-04 | 24, 25, 28, 31 | 0d |  |  |
| 38 | 1.2.3.12 | Ambientes desarrollo/pruebas/preproducción/producción | 5d | 2024-03-05 | 2024-03-11 | 37 | 0d |  |  |
| 39 | 1.2.3.13 | Diseño de la documentación del sistema | 4d | 2024-03-12 | 2024-03-15 | 38 | 0d |  |  |
| 40 | 1.2.4 | Presentación de diseño al arquitecto Cencosud | 1d | 2024-03-18 | 2024-03-18 | 39 | 0d |  |  |
| 41 | 1.2.5 | Diseñar plan y cronograma comunicacional | 2d | 2024-03-19 | 2024-03-20 | 40 | 0d |  |  |
| 42 | 1.3 | **ETAPA DE DESARROLLO** | 60d | 2024-03-21 | 2024-06-12 | 41 | 0d |  |  |
| 43 | 1.3.1 | Crear plan de desarrollo | 5d | 2024-03-21 | 2024-03-27 | 41 | 137d |  | start no earlier than 2024-03-21 |
| 44 | 1.3.2 | **Configuración y validación del ambiente** | 15d | 2024-03-21 | 2024-04-10 | 26 | 0d |  |  |
| 45 | 1.3.2.1 | Configuración y validación del ambiente de desarrollo | 15d | 2024-03-21 | 2024-04-10 | 23 | 0d |  |  |
| 46 | 1.3.2.2 | Configuración y validación del ambiente de pruebas | 15d | 2024-03-21 | 2024-04-10 | 23 | 127d |  |  |
| 47 | 1.3.3 | **Creación del prototipo del sistema de aprovisionamiento automático en la góndola** | 29d | 2024-04-11 | 2024-05-21 | 45 | 98d |  |  |
| 48 | 1.3.3.1 | Desarrollo front/Backend gestión de productos góndola y lineales | 20d | 2024-04-11 | 2024-05-08 | 45 | 98d | 0d |  |
| 49 | 1.3.3.2 | Verificar los componentes del sistema (Interfaz,DB, módulos de abastecimiento) comunicación. | 3d | 2024-05-09 | 2024-05-13 | 48 | 98d | 0d |  |
| 50 | 1.3.3.3 | Evaluar si el sistema cumple con los requerimientos funcionales establecidos. | 3d | 2024-05-09 | 2024-05-13 | 48 | 104d |  |  |
| 51 | 1.3.3.4 | Ajustes sobre los componentes del sistema y funcionales. | 6d | 2024-05-14 | 2024-05-21 | 49 | 98d |  |  |

| ID | WBS | Task | Duration | Start | Finish | Predecessors | Total slack | Free slack |
| --- | --- | --- | --- | --- | --- | --- | --- | --- |
| 52 | 1.3.4 | **Creación del prototipo del sistema de integración e implementación del sistema de inventario** | 25d | 2024-03-21 | 2024-04-24 | 41 | 117d |  |
| 53 | 1.3.4.1 | Crear los datos de simulación del sistema de automatización de Góndolas y lineales | 3d | 2024-03-21 | 2024-03-25 | 41 | 117d | 0d |
| 54 | 1.3.4.2 | Desarrollo front/Backend aprovisionamiento de inventario (interacción con el sistema legado) | 13d | 2024-03-26 | 2024-04-11 | 53 | 117d | 0d |
| 55 | 1.3.4.3 | Verificar los componentes del sistema (Interfaz,DB, módulos de abastecimiento) comunicación. | 4d | 2024-04-12 | 2024-04-17 | 54 | 117d | 0d |
| 56 | 1.3.4.4 | Evaluar si el sistema cumple con los requerimientos funcionales establecidos. | 4d | 2024-04-18 | 2024-04-23 | 55 | 118d |  |
| 57 | 1.3.4.5 | Ajustes sobre los componentes del sistema y funcionales. | 5d | 2024-04-18 | 2024-04-24 | 55 | 117d |  |
| 58 | 1.3.5 | **Creación del prototipo del modelo de gestión de productos de alta rotación** | 35d | 2024-03-21 | 2024-05-08 | 41 | 102d |  |
| 59 | 1.3.5.1 | Crear los datos de simulación de la salida del sistema de inventarios | 5d | 2024-03-21 | 2024-03-27 | 41 | 102d | 0d |
| 60 | 1.3.5.2 | Desarrollo front/Backend modelo de gestión de productos de alta rotación | 20d | 2024-03-28 | 2024-04-24 | 59 | 102d | 0d |
| 61 | 1.3.5.3 | Verificar los componentes del sistema (Interfaz,DB, módulos de abastecimiento) comunicación. | 5d | 2024-04-25 | 2024-05-01 | 60 | 102d | 0d |
| 62 | 1.3.5.4 | Evaluar si el sistema cumple con los requerimientos funcionales establecidos. | 5d | 2024-04-25 | 2024-05-01 | 60 | 112d |  |
| 63 | 1.3.5.5 | Ajustes sobre los componentes del sistema y funcionales. | 5d | 2024-05-02 | 2024-05-08 | 61 | 102d | 0d |
| 64 | 1.3.6 | Desarrollo/pruebas de personalizaciones e interfaces e integración | 5d | 2024-05-09 | 2024-05-15 | 63 | 102d |  |
| 65 | 1.3.7 | **Implementación de homologación y calidad de datos** | 33d | 2024-04-11 | 2024-05-27 | 45 | 0d |  |
| 66 | 1.3.7.1 | Desarrollo de homologación y calidad de datos | 25d | 2024-04-11 | 2024-05-15 | 45 | 0d |  |
| 67 | 1.3.7.2 | Pruebas Técnicas | 3d | 2024-05-16 | 2024-05-20 | 66 | 0d |  |
| 68 | 1.3.7.3 | Ajustes/Pruebas | 5d | 2024-05-21 | 2024-05-27 | 67 | 0d |  |
| 69 | 1.3.8 | Desarrollo de migración de datos | 7d | 2024-05-28 | 2024-06-05 | 65 | 0d |  |
| 70 | 1.3.9 | **Presentación de la primera versión - prototipo del sistema** | 12d | 2024-05-28 | 2024-06-12 | 65 | 82d |  |
| 71 | 1.3.9.1 | Sesión de presentación y retroalimentación a los stakeholders | 5d | 2024-05-28 | 2024-06-03 | 65 | 82d | 0d |
| 72 | 1.3.9.2 | Demostraciones internas | 4d | 2024-06-04 | 2024-06-07 | 71 | 82d | 0d |
| 73 | 1.3.9.3 | Documentación detallada funcionalidades, flujos de diseño. | 3d | 2024-06-10 | 2024-06-12 | 72 | 82d |  |
| 74 | 1.4 | **ETAPA DE PRUEBAS** | 36d | 2024-06-06 | 2024-07-25 |  | 0d |  |
| 75 | 1.4.1 | **Configuración de prerequisitos** | 11d | 2024-06-06 | 2024-06-20 |  | 0d |  |
| 76 | 1.4.1.1 | Identificar los requisitos de prueba. | 2d | 2024-06-06 | 2024-06-07 | 69 | 0d |  |
| 77 | 1.4.1.2 | Diseñar casos de prueba. | 2d | 2024-06-10 | 2024-06-11 | 76 | 0d |  |
| 78 | 1.4.1.3 | Crear datos de prueba. | 3d | 2024-06-12 | 2024-06-14 | 77 | 0d |  |
| 79 | 1.4.1.4 | Configurar el entorno de prueba. | 4d | 2024-06-17 | 2024-06-20 | 78 | 0d |  |

| ID | WBS | Task | Duration | Start | Finish | Predecessors | Total slack |
| --- | --- | --- | --- | --- | --- | --- | --- |
| 80 | 1.4.2 | **Ejecutar pruebas del sistema e integración** | 24d | 2024-06-21 | 2024-07-24 |  | 0d |
| 81 | 1.4.2.1 | Pruebas unitarias. | 3d | 2024-06-21 | 2024-06-25 | 79 | 0d |
| 82 | 1.4.2.2 | Pruebas de integración. | 3d | 2024-06-26 | 2024-06-28 | 81 | 0d |
| 83 | 1.4.2.3 | Pruebas de aceptación del usuario. | 8d | 2024-07-01 | 2024-07-10 | 82 | 0d |
| 84 | 1.4.2.4 | Realizar pruebas de rendimiento. | 3d | 2024-07-11 | 2024-07-15 | 83 | 0d |
| 85 | 1.4.2.5 | Realizar pruebas de seguridad. | 4d | 2024-07-16 | 2024-07-19 | 84 | 0d |
| 86 | 1.4.2.6 | Realizar pruebas de compatibilidad. | 3d | 2024-07-22 | 2024-07-24 | 85 | 0d |
| 87 | 1.4.3 | Documentar los resultados de las pruebas. | 1d | 2024-07-25 | 2024-07-25 | 86 | 0d |
| 88 | 1.5 | **ETAPA DE AJUSTES** | 20d | 2024-07-26 | 2024-08-22 | 87 | 0d |
| 89 | 1.5.1 | **Definición del plan de Ajustes** | 7d | 2024-07-26 | 2024-08-05 |  | 0d |
| 90 | 1.5.1.1 | Identificar los ajustes | 2d | 2024-07-26 | 2024-07-29 | 87 | 18d |
| 91 | 1.5.1.2 | Estimar los ajustes | 2d | 2024-07-26 | 2024-07-29 | 87 | 18d |
| 92 | 1.5.1.3 | Priorizar Ajustes | 2d | 2024-07-26 | 2024-07-29 | 87 | 0d |
| 93 | 1.5.1.4 | Implementar y realizar pruebas | 5d | 2024-07-30 | 2024-08-05 | 92 | 0d |
| 94 | 1.5.2 | **Ejecutar pruebas** | 9d | 2024-08-06 | 2024-08-16 | 93 | 0d |
| 95 | 1.5.2.1 | Pruebas unitarias. | 2d | 2024-08-06 | 2024-08-07 | 93 | 0d |
| 96 | 1.5.2.2 | Pruebas de integración. | 2d | 2024-08-08 | 2024-08-09 | 95 | 0d |
| 97 | 1.5.2.3 | Pruebas de aceptación del usuario. | 2d | 2024-08-12 | 2024-08-13 | 96 | 0d |
| 98 | 1.5.2.4 | Realizar pruebas de rendimiento. | 1d | 2024-08-14 | 2024-08-14 | 97 | 0d |
| 99 | 1.5.2.5 | Realizar pruebas de seguridad. | 1d | 2024-08-15 | 2024-08-15 | 98 | 0d |
| 100 | 1.5.2.6 | Realizar pruebas de compatibilidad. | 1d | 2024-08-16 | 2024-08-16 | 99 | 0d |
| 101 | 1.5.3 | Actualización de la documentación | 4d | 2024-08-19 | 2024-08-22 | 94 | 0d |
| 102 | 1.6 | **ETAPA DE DESPLIEGUE** | 27d | 2024-08-23 | 2024-09-30 | 88 | 0d |
| 103 | 1.6.1 | Validación del ambiente preproductivo y productivo | 5d | 2024-08-23 | 2024-08-29 | 88 | 0d |

| ID | WBS | Task | Duration | Start | Finish | Predecessors | Total slack | Free slack |
| --- | --- | --- | --- | --- | --- | --- | --- | --- |
| 104 | 1.6.2 | **DESPLIEGUE MARCHA BLANCA** | 16d | 2024-08-30 | 2024-09-20 |  | 0d |  |
| 105 | 1.6.2.1 | Implementación Plan de etapa de despliegue | 4d | 2024-08-30 | 2024-09-04 | 103 | 0d |  |
| 106 | 1.6.2.2 | Actualización plan de carga | 3d | 2024-09-05 | 2024-09-09 | 105 | 4d | 0d |
| 107 | 1.6.2.3 | Capacitación de los usuarios claves | 4d | 2024-09-10 | 2024-09-13 | 106 | 15d |  |
| 108 | 1.6.2.4 | Migración de datos | 3d | 2024-09-10 | 2024-09-12 | 106 | 4d | 0d |
| 109 | 1.6.2.5 | Implementación Supermercado #1. Tienda Piloto. | 1d | 2024-09-13 | 2024-09-13 | 108 | 4d | 0d |
| 110 | 1.6.2.6 | Monitoreo Tienda Piloto | 3d | 2024-09-16 | 2024-09-18 | 109 | 4d | 0d |
| 111 | 1.6.2.7 | Estabilización del servicio | 2d | 2024-09-19 | 2024-09-20 | 110 | 4d | 0d |
| 112 | 1.6.3 | **GO LIVE** | 6d | 2024-09-23 | 2024-09-30 | 111 | 4d |  |
| 113 | 1.6.3.1 | **FASE 1** | 6d | 2024-09-23 | 2024-09-30 |  | 4d |  |
| 114 | 1.6.3.1.1 | Implementación Supermercado # 2 | 1d | 2024-09-23 | 2024-09-23 | 111 | 4d | 0d |
| 115 | 1.6.3.1.2 | Monitoreo Tiendas | 3d | 2024-09-24 | 2024-09-26 | 114 | 4d | 0d |
| 116 | 1.6.3.1.3 | Estabilización del servicio | 2d | 2024-09-27 | 2024-09-30 | 115 | 4d |  |
| 117 | 1.6.3.2 | **FASE 2** | 6d | 2024-09-23 | 2024-09-30 |  | 4d |  |
| 118 | 1.6.3.2.1 | Implementación Supermercado # 3 | 1d | 2024-09-23 | 2024-09-23 | 111 | 4d | 0d |
| 119 | 1.6.3.2.2 | Monitoreo Tiendas | 3d | 2024-09-24 | 2024-09-26 | 118 | 4d | 0d |
| 120 | 1.6.3.2.3 | Estabilización del servicio | 2d | 2024-09-27 | 2024-09-30 | 119 | 4d |  |
| 121 | 1.6.3.3 | **FASE 3** | 6d | 2024-09-23 | 2024-09-30 |  | 4d |  |
| 122 | 1.6.3.3.1 | Implementación Supermercado # 4 | 1d | 2024-09-23 | 2024-09-23 | 111 | 4d | 0d |
| 123 | 1.6.3.3.2 | Monitoreo Tiendas | 3d | 2024-09-24 | 2024-09-26 | 122 | 4d | 0d |
| 124 | 1.6.3.3.3 | Estabilización del servicio | 2d | 2024-09-27 | 2024-09-30 | 123 | 4d |  |
| 125 | 1.6.4 | **Gestión del Cambio** | 14d | 2024-08-30 | 2024-09-18 |  | 4d |  |
| 126 | 1.6.4.1 | **Ejecución del plan de gestión de conocimiento** | 12d | 2024-08-30 | 2024-09-16 | 103 | 14d |  |
| 127 | 1.6.4.1.1 | Identificar y recopilar información relevante | 3d | 2024-08-30 | 2024-09-03 | 103 | 14d | 0d |
| 128 | 1.6.4.1.2 | Almacenamiento del conocimiento | 3d | 2024-09-04 | 2024-09-06 | 127 | 14d | 0d |
| 129 | 1.6.4.1.3 | Distribución del conocimiento | 3d | 2024-09-09 | 2024-09-11 | 128 | 14d | 0d |
| 130 | 1.6.4.1.4 | Integración de procesos | 1d | 2024-09-12 | 2024-09-12 | 129 | 14d | 0d |
| 131 | 1.6.4.1.5 | Evaluación y mejora continua | 2d | 2024-09-13 | 2024-09-16 | 130 | 14d |  |

| ID | WBS | Task | Duration | Start | Finish | Predecessors | Total slack | Free slack |
| --- | --- | --- | --- | --- | --- | --- | --- | --- |
| 132 | 1.6.4.2 | **Ejecución del plan de entrega a la operación** | 11d | 2024-08-30 | 2024-09-13 | 103 | 15d |  |
| 133 | 1.6.4.2.1 | Validar el inventario de entrega a la operación | 4d | 2024-08-30 | 2024-09-04 | 103 | 15d | 0d |
| 134 | 1.6.4.2.2 | Realizar sesiones de entrega | 3d | 2024-09-05 | 2024-09-09 | 133 | 15d | 0d |
| 135 | 1.6.4.2.3 | Entrega de documentación | 4d | 2024-09-10 | 2024-09-13 | 134 | 15d |  |
| 136 | 1.6.4.3 | Ejecución del plan de gestión del cambio | 8d | 2024-09-05 | 2024-09-16 | 105 | 0d |  |
| 137 | 1.6.4.4 | Ejecución de envío de comunicados. | 2d | 2024-09-17 | 2024-09-18 | 136 | 0d |  |
| 138 | 1.7 | **ETAPA DE CIERRE** | 12d | 2024-09-19 | 2024-10-04 | 137 | 0d |  |
| 139 | 1.7.1 | Presentación de resultados | 1d | 2024-09-19 | 2024-09-19 | 137 | 0d |  |
| 140 | 1.7.2 | Actualización de documentación | 5d | 2024-09-20 | 2024-09-26 | 139 | 0d |  |
| 141 | 1.7.3 | Evaluación y encuesta feedback clientes | 2d | 2024-09-27 | 2024-09-30 | 140 | 0d |  |
| 142 | 1.7.4 | Cierre de contratos | 2d | 2024-10-01 | 2024-10-02 | 141 | 0d |  |
| 143 | 1.7.5 | Cierre de finanzas | 2d | 2024-10-03 | 2024-10-04 | 142 | 0d |  |
| 144 | 1.7.6 | Verificación de reasignación de miembros del equipo | 1d | 2024-09-27 | 2024-09-27 | 140 | 5d |  |
| 145 | 1.7.7 | Documentación lecciones aprendidas | 1d | 2024-09-27 | 2024-09-27 | 140 | 4d | 0d |
| 146 | 1.7.8 | Entrega del informe final | 1d | 2024-09-30 | 2024-09-30 | 145 | 4d |  |
| 147 | 1.7.9 | Formulación y firma documento de cierre | 1d | 2024-09-30 | 2024-09-30 | 145 | 4d |  |
